# Cooling_plan_3Oct2003

How a schedule from MS Project changed from version to version. A marks actual dates.

## Version 1 (saved 2003-10-03, file Cooling_plan_3Oct2003.mpp)

| ID | WBS | Task | Duration | Start | Finish | Predecessors | Total float | Constraint |
| --- | --- | --- | --- | --- | --- | --- | --- | --- |
| 1 | 1 | **Test at CERN** | 155d? | 2003-07-07 | 2004-02-06 |  | 1d |  |
| 2 | 1.1 | **Setup improvement** | 30d? | 2003-09-08 | 2003-10-17 |  | 4d |  |
| 3 |  | procure liquid flow meter and pressure sensors | 30d? | 2003-09-08 | 2003-10-17 |  | 4d | start no earlier than 2003-09-08 |
| 4 |  | Complete tests on Pixel heat exchanger | 12d? | 2003-10-02 | 2003-10-17 |  | 0d | start no earlier than 2003-10-02 |
| 5 | 1.3 | **Heater** | 29d | 2003-09-17 | 2003-10-27 |  | 0d |  |
| 6 |  | new heater control | 23d | 2003-09-17 | 2003-10-17 |  | 0d | start no earlier than 2003-09-17 |
| 7 |  | test final heater prototypes | 4d | 2003-10-20 | 2003-10-23 | 4, 6 | 0d |  |
| 8 |  | Report on the heater tests for the review | 2d | 2003-10-24 | 2003-10-27 | 7 | 80d |  |
| 9 |  | PRR of external system | 0d | 2003-11-05 | 2003-11-05 | 8 | 32d | start no earlier than 2003-11-05 |
| 10 | 1.5 | **Capillary** | 89d? | 2003-07-07 | 2003-11-06 |  | 0d |  |
| 11 |  | procurement of capillaries (0.6/0.65/0.7 ID) | 75d? | 2003-07-07 | 2003-10-17 |  | 11d | start no earlier than 2003-07-05 |
| 12 |  | Measure ID and prepare test samples | 3d | 2003-10-20 | 2003-10-22 | 11 | 11d |  |
| 13 |  | Capillary tests | 10d | 2003-10-24 | 2003-11-06 | 7, 12, 3 | 0d | start no earlier than 2003-09-06 |
| 14 | 1.6 | **study of EC SCT heat exchanger** | 30d | 2003-11-07 | 2003-12-18 |  | 0d |  |
| 15 |  | New prototype with final capillary | 3d | 2003-11-07 | 2003-11-11 | 13 | 0d |  |
| 16 |  | test prototype | 21d | 2003-11-12 | 2003-12-10 | 15 | 0d |  |
| 17 |  | Final report on heat exchanger and capillary tests | 6d | 2003-12-11 | 2003-12-18 | 16 | 42d |  |
| 18 | 1.7 | **Filter** | 94d? | 2003-09-30 | 2004-02-06 |  | 23d |  |
| 19 |  | Procure samples for both barrel and EC SCT | 19d | 2003-09-30 | 2003-10-24 |  | 70d | start no earlier than 2003-09-30 |
| 20 |  | design fitting with filter | 19d? | 2003-09-30 | 2003-10-24 |  | 70d | start no earlier than 2003-09-30 |
| 21 |  | prototype of fitting with filter | 8d? | 2003-10-27 | 2003-11-05 | 20, 19 | 70d | start no earlier than 2003-08-27 |
| 22 |  | test filter on cooling loop | 3d | 2003-11-07 | 2003-11-11 | 13, 21 | 69d |  |
| 23 | 1.7.5 | **Liquid Setup for capillary trimming to right length** | 41d | 2003-12-12 | 2004-02-06 |  | 6d |  |
| 24 |  | Design | 7d | 2003-12-12 | 2003-12-22 |  | 6d | start no earlier than 2003-12-12 |
| 25 |  | Material procurement | 21d | 2003-12-23 | 2004-01-20 | 24 | 6d |  |
| 26 |  | Assembly | 10d | 2004-01-21 | 2004-02-03 | 25 | 6d |  |
| 27 |  | Testing | 3d | 2004-02-04 | 2004-02-06 | 26 | 6d |  |
| 28 | 2 | **Design and Manufacturing of SCT EC heat exchanger** | 116d? | 2003-10-01 | 2004-03-10 |  | 0d |  |
| 29 |  | Detailed design | 27d? | 2003-10-01 | 2003-11-06 |  | 3d | start no earlier than 2003-10-01 |
| 30 |  | Bidding | 21d | 2003-11-07 | 2003-12-05 | 29 | 3d |  |
| 31 |  | Final design and approval | 5d | 2003-12-11 | 2003-12-17 | 30, 16 | 0d |  |
| 32 |  | Place orders for parts | 0d | 2003-12-17 | 2003-12-17 | 31 | 0d |  |
| 33 |  | Procurement | 43d | 2003-12-18 | 2004-02-16 | 32 | 0d |  |
| 34 |  | Testing of capillaries | 3d | 2004-02-17 | 2004-02-19 | 33, 27 | 0d |  |
| 35 |  | Assembly of heat exchanger for 1st disk | 10d | 2004-02-20 | 2004-03-04 | 34 | 0d |  |
| 36 |  | Final testing | 4d | 2004-03-05 | 2004-03-10 | 35 | 0d |  |
| 37 |  | HEAT EXCHANGERs READY FOR DISK NO. 1 | 0d | 2004-03-10 | 2004-03-10 | 36 | 0d |  |

## Version 2 (saved 2003-11-07, file Cooling_plan_7Nov2003.mpp)

Last finish 2004-03-10 → 2004-03-12 (+2d). Complete tasks 0 → 3.

Removed: 9 PRR of external system

Changed:

| ID | Task | Start | Finish | Duration | Complete | Total float | Predecessors | Other |
| --- | --- | --- | --- | --- | --- | --- | --- | --- |
| 1 | **Test at CERN** | 2003-07-07 A | 2004-02-06 → 2003-12-22 (-46d) | 155d? → 121d? | 0% → 77% | 1d → 59d |  |  |
| 2 | **Setup improvement** | 2003-09-08 A | 2003-10-17 → 2003-11-12 (+26d) | 30d? → 48d? | 0% → 80% | 4d → 1d |  |  |
| 3 | procure liquid flow meter and pressure sensors | 2003-09-08 A | 2003-10-17 → 2003-11-12 (+26d) | 30d? → 48d? | 0% → 80% | 4d → 1d |  |  |
| 4 | Complete tests on Pixel heat exchanger | 2003-10-02 A | 2003-10-17 A |  | 0% → 100% | 0d → none |  |  |
| 5 | **Heater** | 2003-09-17 A | 2003-10-27 → 2003-11-13 (+17d) | 29d → 42d | 0% → 79% | 0d → 86d |  |  |
| 6 | new heater control | 2003-09-17 A | 2003-10-17 A |  | 0% → 100% | 0d → none |  |  |
| 7 | test final heater prototypes | 2003-10-20 → 2003-10-19 A (-1d) | 2003-10-23 → 2003-11-10 (+18d) | 4d → 16d | 0% → 53% | 0d → 6d |  |  |
| 8 | Final report on the heater tests | 2003-10-24 → 2003-11-12 A (+19d) | 2003-10-27 → 2003-11-13 (+17d) |  | 0% → 50% | 80d → 86d |  | was named Report on the heater tests for the review; resources Stephane → Bogdan; Richard B. |
| 9 | **Capillary** | 2003-07-07 A | 2003-11-06 → 2003-11-21 (+15d) | 89d? → 100d? | 0% → 88% |  |  |  |
| 10 | procurement of capillaries (0.6/0.65/0.7 ID) | 2003-07-07 A | 2003-10-17 A |  | 0% → 100% | 11d → none |  |  |
| 11 | Measure ID and prepare test samples | 2003-10-20 → 2003-11-03 A (+14d) | 2003-10-22 → 2003-11-13 (+22d) | 3d → 9d | 0% → 50% | 11d → 0d | 10 → none | constraint none → start no earlier than 2003-11-02 |
| 12 | Capillary tests | 2003-10-24 → 2003-11-14 (+21d) | 2003-11-06 → 2003-11-21 (+15d) | 10d → 6d |  |  | 7, 11, 3 → 7FS-3d, 11, 3 |  |
| 13 | **study of EC SCT heat exchanger** | 2003-11-07 → 2003-11-24 (+17d) | 2003-12-18 → 2003-12-22 (+4d) | 30d → 21d |  |  |  |  |
| 14 | New prototype with final capillary | 2003-11-07 → 2003-11-24 (+17d) | 2003-11-11 → 2003-11-26 (+15d) |  |  |  | 12 → 12, 20 | resources Pierre → Pierre; Valery |
| 15 | test prototype | 2003-11-12 → 2003-11-27 (+15d) | 2003-12-10 → 2003-12-12 (+2d) | 21d → 12d |  |  |  |  |
| 16 | Final report on heat exchanger and capillary tests | 2003-12-11 → 2003-12-15 (+4d) | 2003-12-18 → 2003-12-22 (+4d) |  |  | 42d → 59d |  |  |
| 17 | **Filter** |  | 2004-02-06 → 2003-12-01 (-67d) | 94d? → 45d? |  | 23d → 0d |  |  |
| 20 | prototype of fitting with filter |  | 2003-11-05 → 2003-11-21 (+16d) | 8d? → 20d? |  | 70d → 0d |  |  |
| 21 | test filter on cooling loop | 2003-11-07 → 2003-11-27 (+20d) | 2003-11-11 → 2003-12-01 (+20d) |  |  | 69d → 74d | 12, 20 → 20FS+3d |  |
| 27 | **Design and Manufacturing of SCT EC heat exchanger** | 2003-10-01 A | 2004-03-10 → 2004-03-12 (+2d) | 116d? → 118d? | 0% → 13% |  |  |  |
| 28 | Detailed design | 2003-10-01 A | 2003-11-06 → 2003-11-11 (+5d) | 27d? → 30d? | 0% → 50% | 3d → 2d |  |  |
| 29 | Bidding | 2003-11-07 → 2003-11-12 (+5d) | 2003-12-05 → 2003-12-10 (+5d) |  |  | 3d → 2d |  |  |
| 30 | Final design and approval | 2003-12-11 → 2003-12-15 (+4d) | 2003-12-17 → 2003-12-19 (+2d) |  |  |  |  |  |
| 31 | Place orders for parts | 2003-12-17 → 2003-12-19 (+2d) | 2003-12-17 → 2003-12-19 (+2d) |  |  |  |  |  |
| 32 | Procurement | 2003-12-18 → 2003-12-22 (+4d) | 2004-02-16 → 2004-02-18 (+2d) |  |  |  |  |  |
| 33 | Testing of capillaries | 2004-02-17 → 2004-02-19 (+2d) | 2004-02-19 → 2004-02-23 (+4d) |  |  |  |  |  |
| 34 | Assembly of heat exchanger for 1st disk | 2004-02-20 → 2004-02-24 (+4d) | 2004-03-04 → 2004-03-08 (+4d) |  |  |  |  |  |
| 35 | Final testing | 2004-03-05 → 2004-03-09 (+4d) | 2004-03-10 → 2004-03-12 (+2d) |  |  |  |  |  |
| 36 | HEAT EXCHANGERs READY FOR DISK NO. 1 | 2004-03-10 → 2004-03-12 (+2d) | 2004-03-10 → 2004-03-12 (+2d) |  |  |  |  |  |
